Schedule from MS Project, 2002-02-15 to 2003-01-10, A marks actual dates.
Lawrence Livermore National Laboratory

## Calendars

- Standard: Mon-Fri 08:00-12:00, 13:00-17:00; Sat-Sun off.

## Schedule

| ID | WBS | Task | Type | Duration | Start | Finish | Predecessors | Complete | Remaining | Baseline start | Baseline finish | Baseline duration | Total slack | Free slack | Constraint |
| --- | --- | --- | --- | --- | --- | --- | --- | --- | --- | --- | --- | --- | --- | --- | --- |
| 1 | 1 | **Software** |  | 215d | 2002-02-18 A | 2002-12-13 |  | 80% | 43d | 2002-02-18 | 2002-12-13 | 215d | 20d |  |  |
| 2 | 1.1 | Initial Simulations |  | 4mo | 2002-02-18 A | 2002-06-07 A |  | 100% |  | 2002-02-18 | 2002-06-07 | 4mo |  |  | start no earlier than 2002-02-18 |
| 3 | 1.2 | Write Online/ Monitoring software |  | 1mo | 2002-11-18 | 2002-12-13 | 27 |  |  | 2002-10-21 | 2002-12-13 | 2mo | 20d |  |  |
| 4 | 2 | **Pre-work/Calorimeter Tests** |  | 50d | 2002-02-15 A | 2002-04-25 |  | 99% | 0d | 2002-02-15 | 2002-04-25 | 50d | 166d |  |  |
| 5 | 2.1 | Calorimeter testing |  | 2.5mo | 2002-02-15 A | 2002-04-25 A |  | 100% |  | 2002-02-15 | 2002-04-25 | 2.5mo |  |  | start no earlier than 2002-02-15 |
| 6 | 2.2 | Final Choice of Detector | milestone | 0d | 2002-04-25 | 2002-04-25 | 5 |  |  | 2002-04-25 | 2002-04-25 | 0d | 166d |  |  |
| 7 | 2.3 | Ship FNAL detector to BNL |  | 2w | 2002-04-08 A | 2002-04-19 A |  | 100% |  | 2002-04-08 | 2002-04-19 | 2w |  |  | start no earlier than 2002-04-08 |
| 8 | 3 | **Hardware construction** |  | 110d | 2002-06-03 A | 2002-11-01 | 7 | 48% | 56.67d | 2002-06-03 | 2002-10-04 | 90d | 20d |  |  |
| 9 | 3.1 | Finalize geometry | milestone | 0d | 2002-06-07 | 2002-06-07 | 2 |  |  | 2002-06-07 | 2002-06-07 | 0d | 115d | 110d |  |
| 10 | 3.2 | Design Stand(s) |  | 2mo | 2002-06-10 A | 2002-08-02 A | 9 | 100% |  | 2002-06-10 | 2002-08-02 | 2mo |  |  |  |
| 11 | 3.3 | Build Stand |  | 2mo | 2002-08-05 | 2002-09-27 | 10 |  |  |  |  |  | 20d | 0d |  |
| 12 | 3.4 | Build Cosmic DAQ |  | 1mo | 2002-06-03 A | 2002-06-28 A |  | 100% |  | 2002-06-03 | 2002-06-28 | 1mo |  |  | start no earlier than 2002-06-03 |
| 13 | 3.5 | Extract Calorimetry modules |  | 2mo | 2002-07-01 A | 2002-08-23 | 12 | 50% | 1mo | 2002-07-01 | 2002-08-23 | 2mo | 25d |  |  |
| 14 | 3.6 | Stack modules on Stand |  | 2w | 2002-09-30 | 2002-10-11 | 13, 11 |  |  |  |  |  | 20d | 0d |  |
| 15 | 3.7 | Placement in beam area |  | 2w | 2002-10-14 | 2002-10-25 | 14 |  |  | 2002-08-26 | 2002-09-20 | 1mo | 20d | 0d |  |
| 16 | 3.8 | Cable Detector |  | 1w | 2002-10-28 | 2002-11-01 | 9, 15 |  |  | 2002-09-23 | 2002-10-04 | 2w | 20d | 0d |  |
| 17 | 4 | **Low Voltage** |  | 40d | 2002-07-29 A | 2002-09-20 |  | 38% | 25d |  |  |  | 5d |  |  |
| 18 | 4.1 | Low Voltage Design |  | 1mo | 2002-07-29 A | 2002-08-23 |  | 75% | 0.25mo |  |  |  | 5d | 0d | start no earlier than 2002-07-29 |
| 19 | 4.2 | Low Voltage Construction |  | 1mo | 2002-08-26 | 2002-09-20 | 18 |  |  |  |  |  | 5d | 0d |  |
| 20 | 5 | **FEE** |  | 180d | 2002-03-11 A | 2002-11-15 |  | 54% | 82.89d | 2002-03-11 | 2002-10-18 | 160d | 20d |  |  |
| 21 | 5.1 | Review Trigger Issues |  | 1.05mo | 2002-03-11 A | 2002-04-08 A |  | 100% |  | 2002-03-11 | 2002-04-08 | 1.05mo |  |  | start no earlier than 2002-03-11 |
| 22 | 5.2 | Finalize trigger choice | milestone | 0d | 2002-04-08 | 2002-04-08 | 21 |  |  | 2002-04-08 | 2002-04-08 | 0d | 179d |  |  |
| 23 | 5.3 | Electronics Studies |  | 1mo | 2002-04-09 A | 2002-05-06 A | 22 | 100% |  | 2002-04-09 | 2002-05-06 | 1mo |  |  |  |
| 24 | 5.4 | Electronics decision | milestone | 0d | 2002-05-06 | 2002-05-06 | 23 |  |  | 2002-05-06 | 2002-05-06 | 0d | 159d |  |  |
| 25 | 5.5 | Full Scale Test in 1008 |  | 3w | 2002-09-23 | 2002-10-11 | 19 |  |  |  |  |  | 5d | 0d |  |
| 26 | 5.6 | Install FEE |  | 2w | 2002-10-14 | 2002-10-25 | 25 |  |  | 2002-09-23 | 2002-10-04 | 2w | 5d |  |  |
| 27 | 5.7 | Test with in tunnel |  | 2w | 2002-11-04 | 2002-11-15 | 26, 16 |  |  | 2002-10-07 | 2002-10-18 | 2w | 20d | 0d |  |

| ID | WBS | Task | Type | Duration | Start | Finish | Predecessors | Baseline start | Baseline finish | Baseline duration | Total slack | Constraint |
| --- | --- | --- | --- | --- | --- | --- | --- | --- | --- | --- | --- | --- |
| 28 | 6 | **Integration** |  | 40d | 2002-11-18 | 2003-01-10 | 27 | 2002-10-21 | 2002-12-13 | 40d | 0d |  |
| 29 | 6.1 | Tie into DAQ |  | 1mo | 2002-11-18 | 2002-12-13 |  | 2002-10-21 | 2002-12-13 | 2mo | 20d |  |
| 30 | 6.2 | Calibration |  | 1mo | 2002-12-16 | 2003-01-10 | 27, 33 | 2002-10-21 | 2002-11-15 | 1mo | 0d |  |
| 31 | 7 | Cooldown | milestone | 0d | 2002-11-01 | 2002-11-01 |  |  |  |  | 31d | start no earlier than 2002-11-01 |
| 32 | 8 | Shield Wall Up | milestone | 0d | 2002-12-02 | 2002-12-02 |  |  |  |  | 30d | start no earlier than 2002-12-02 |
| 33 | 9 | Run III Starts | milestone | 0d | 2002-12-16 | 2002-12-16 |  | 2002-11-01 | 2002-11-01 | 0d | 0d | start no earlier than 2002-12-16 |
